# SCM Professionalisation Implementation Approach for Health SC

Schedule from MS Project, 2021-01-01 to 2023-11-21.

## Calendars

- Standard: Mon-Fri 08:00-12:00, 13:00-17:00; Sat-Sun off.

## Resources

| Resource |
| --- |
| Policy Working Group |
| Education and Academia Working Group |
| Supply Chain Processes Working Group |
| Technology Working Group |
| Human Resources Working Group |
| Professional Association Working Group |
| Change Management Working Group |

## Schedule

| ID | WBS | Task | Type | Duration | Start | Finish | Predecessors | Total slack | Constraint | Resources | Work |
| --- | --- | --- | --- | --- | --- | --- | --- | --- | --- | --- | --- |
| 1 | 1 | **SCM Professionalisation Framework: Implementation Approach for Health Supply Chains** |  | 753d | 2021-01-01 | 2023-11-21 |  | 0d |  |  | 24504h |
| 2 | 1.1 | **S3: HR4SCM Building Blocks** |  | 300d | 2021-01-01 | 2022-02-24 |  | 0d |  |  | 9520h |
| 3 | 1.1.1 | **3.1 SC Process Activity Selection** |  | 60d | 2021-01-01 | 2021-03-25 |  | 0d |  |  | 3360h |
| 4 | 1.1.1.1 | Gathering of process documentation from all organisations |  | 30d | 2021-01-01 | 2021-02-11 |  | 0d | start no earlier than 2021-01-01 | Change Management Working Group; Human Resources Working Group; Policy Working Group; Supply Chain Processes Working Group; Technology Working Group | 1200h |
| 5 | 1.1.1.2 | Gathering of human resource assignments |  | 30d | 2021-01-01 | 2021-02-11 |  | 0d | start no earlier than 2021-01-01 | Human Resources Working Group | 240h |
| 6 | 1.1.1.3 | Selection of processes from original scope defined in project charter |  | 30d | 2021-01-01 | 2021-02-11 |  | 0d | start no earlier than 2021-01-01 | Human Resources Working Group; Policy Working Group; Supply Chain Processes Working Group | 720h |
| 7 | 1.1.1.4 | Gather Educational course data for health supply chain |  | 30d | 2021-01-01 | 2021-02-11 |  | 0d | start no earlier than 2021-01-01 | Education and Academia Working Group | 240h |
| 8 | 1.1.1.5 | Gather professional association data and requirements looking for supply chain custodianship |  | 30d | 2021-01-01 | 2021-02-11 |  | 723d | start no earlier than 2021-01-01 | Policy Working Group; Professional Association Working Group | 480h |
| 9 | 1.1.1.6 | Evaluation of process elements for competency framework |  | 30d | 2021-02-12 | 2021-03-25 | 4, 5, 6, 7 | 0d | start no earlier than 2021-01-01 | Policy Working Group; Supply Chain Processes Working Group | 480h |
| 10 | 1.1.2 | **3.2 Role Alignment** |  | 40d | 2021-03-26 | 2021-05-20 |  | 0d |  |  | 800h |
| 11 | 1.1.2.1 | Definition of designation competencies with qualification and professional credentialing |  | 10d | 2021-03-26 | 2021-04-08 | 9 | 0d |  | Human Resources Working Group; Policy Working Group; Professional Association Working Group; Supply Chain Processes Working Group | 320h |
| 12 | 1.1.2.2 | Alignment of SCM process process to Repository of Job Descriptions |  | 10d | 2021-04-09 | 2021-04-22 | 11 | 0d |  | Human Resources Working Group; Supply Chain Processes Working Group | 160h |
| 13 | 1.1.2.3 | Alignment of SCM job roles to designation level |  | 10d | 2021-04-23 | 2021-05-06 | 12 | 0d |  | Education and Academia Working Group; Human Resources Working Group; Professional Association Working Group | 240h |
| 14 | 1.1.2.4 | Alignment of additional designation requirements |  | 10d | 2021-05-07 | 2021-05-20 | 13 | 0d |  | Professional Association Working Group | 80h |
| 15 | 1.1.3 | **3.3 HR Requirements Analysis** |  | 120d | 2021-05-21 | 2021-11-04 |  | 0d |  | Change Management Working Group; Human Resources Working Group | 4320h |
| 16 | 1.1.3.1 | Comparison of Current Organisation Organogram and associated job descriptions to New Country specific Repository of Job Descriptions |  | 30d | 2021-05-21 | 2021-07-01 | 14 | 0d |  | Education and Academia Working Group; Human Resources Working Group; Professional Association Working Group | 720h |
| 17 | 1.1.3.2 | Comparison of competencies in job descriptions to education availability |  | 30d | 2021-07-02 | 2021-08-12 | 16 | 0d |  | Education and Academia Working Group; Policy Working Group; Professional Association Working Group | 720h |
| 18 | 1.1.3.3 | Definition of total in-country qualification, professional credentialing offering gap |  | 30d | 2021-08-13 | 2021-09-23 | 17 | 0d |  | Education and Academia Working Group; Human Resources Working Group | 480h |
| 19 | 1.1.3.4 | Creation of competency-based assessments by job role |  | 30d | 2021-09-24 | 2021-11-04 | 18 | 0d |  | Human Resources Working Group; Professional Association Working Group | 480h |
| 20 | 1.1.4 | **3.4 Role based competency assessment** |  | 40d | 2021-11-05 | 2021-12-30 |  | 0d |  |  | 640h |
| 21 | 1.1.4.1 | Assessment assignment and measurement |  | 30d | 2021-11-05 | 2021-12-16 | 19 | 0d |  | Change Management Working Group; Human Resources Working Group | 480h |
| 22 | 1.1.4.2 | Optimisation of educational requirements |  | 10d | 2021-12-17 | 2021-12-30 | 21 | 0d |  | Education and Academia Working Group; Human Resources Working Group | 160h |
| 23 | 1.1.5 | **3.5 SC and HR Performance Alignment** |  | 40d | 2021-12-31 | 2022-02-24 |  | 0d |  |  | 400h |
| 24 | 1.1.5.1 | Analyse and document key supply chain performance indicators against training needs |  | 10d | 2021-12-31 | 2022-01-13 | 22 | 0d |  | Human Resources Working Group; Supply Chain Processes Working Group | 160h |
| 25 | 1.1.5.2 | Compare KPIs to interventions identified in previous step and rank according to KPIs |  | 10d | 2022-01-14 | 2022-01-27 | 24 | 0d |  | Supply Chain Processes Working Group | 80h |
| 26 | 1.1.5.3 | Develop Capacity Development Priorities with Individual and Staff Component |  | 10d | 2022-01-28 | 2022-02-10 | 25 | 0d |  | Human Resources Working Group | 80h |
| 27 | 1.1.5.4 | Acquire approval for Capacity Development Priorities with Individual and Staff Component |  | 10d | 2022-02-11 | 2022-02-24 | 26 | 0d |  | Human Resources Working Group | 80h |
| 28 | 1.2 | Sign off for Capacity Development Plan | milestone | 1d | 2022-02-25 | 2022-02-25 | 23 | 0d |  |  |  |

| ID | WBS | Task | Type | Duration | Start | Finish | Predecessors | Total slack | Resources | Work |
| --- | --- | --- | --- | --- | --- | --- | --- | --- | --- | --- |
| 29 | 1.3 | **S4: Improve** |  | 181d | 2022-02-28 | 2022-11-07 |  | 0d |  | 4744h |
| 30 | 1.3.1 | **4.1 Develop Professionalisation Plan** |  | 60d | 2022-02-28 | 2022-05-20 |  | 0d |  | 2880h |
| 31 | 1.3.1.1 | Develop plans based on optimisation quantifying the number and potential time horizon of interventions |  | 60d | 2022-02-28 | 2022-05-20 | 28 | 0d | Human Resources Working Group | 480h |
| 32 | 1.3.1.2 | Develop Professional Council Activities |  | 60d | 2022-02-28 | 2022-05-20 | 28 | 0d | Professional Association Working Group | 480h |
| 33 | 1.3.1.3 | Develop Organisation Activities |  | 60d | 2022-02-28 | 2022-05-20 | 28 | 0d | Human Resources Working Group | 480h |
| 34 | 1.3.1.4 | Develop Country Activities |  | 60d | 2022-02-28 | 2022-05-20 | 28 | 0d | Change Management Working Group | 480h |
| 35 | 1.3.1.5 | Develop Academic Activities |  | 60d | 2022-02-28 | 2022-05-20 | 28 | 0d | Education and Academia Working Group | 480h |
| 36 | 1.3.1.6 | Engage with professional bodies to assist in professionalisation activities |  | 60d | 2022-02-28 | 2022-05-20 | 28 | 0d | Professional Association Working Group | 480h |
| 37 | 1.3.2 | **4.2 Create Personal Development Plans** |  | 60d | 2022-05-23 | 2022-08-12 |  | 0d |  | 720h |
| 38 | 1.3.2.1 | Review role-based recommendation from Capacity Development Plan including CPD requirements |  | 15d | 2022-05-23 | 2022-06-10 | 30 | 0d | Human Resources Working Group | 120h |
| 39 | 1.3.2.2 | Analyse individual recommendation from Capacity Development Plan including CPD requirements |  | 15d | 2022-06-13 | 2022-07-01 | 38 | 0d | Human Resources Working Group | 120h |
| 40 | 1.3.2.3 | Individual conversations based on HR recommendation from Capacity Development Plan |  | 15d | 2022-07-04 | 2022-07-22 | 39 | 0d | Change Management Working Group; Human Resources Working Group | 240h |
| 41 | 1.3.2.4 | Develop individualplans and get buy in from employee |  | 15d | 2022-07-25 | 2022-08-12 | 40 | 0d | Change Management Working Group; Human Resources Working Group | 240h |
| 42 | 1.3.3 | **4.3 Develop Organisational Capacity Development Plan** |  | 40d | 2022-08-15 | 2022-10-07 |  | 0d |  | 424h |
| 43 | 1.3.3.1 | Prepare schedule of groups of employees against professionalisation plan and PDPs |  | 13d | 2022-08-15 | 2022-08-31 | 37 | 0d | Human Resources Working Group; Change Management Working Group | 208h |
| 44 | 1.3.3.2 | Prepare Costing for proposed interventions |  | 14d | 2022-09-01 | 2022-09-20 | 43 | 0d | Human Resources Working Group | 112h |
| 45 | 1.3.3.3 | Balance interventions against funding and budgetary constraints |  | 13d | 2022-09-21 | 2022-10-07 | 44 | 0d | Human Resources Working Group | 104h |
| 46 | 1.3.4 | **4.5 Organisation Improvement Summary** |  | 20d | 2022-10-10 | 2022-11-04 |  | 0d |  | 720h |
| 47 | 1.3.4.1 | Quantify costs for professionalisation |  | 10d | 2022-10-10 | 2022-10-21 | 42 | 0d | Human Resources Working Group; Professional Association Working Group | 160h |
| 48 | 1.3.4.2 | Qualify benefits to professionalisation and position it in the larger HR landscape (Theory of Change) |  | 10d | 2022-10-10 | 2022-10-21 | 42 | 0d | Human Resources Working Group; Policy Working Group; Professional Association Working Group | 240h |
| 49 | 1.3.4.3 | Perform advocacy for on-going professional development |  | 10d | 2022-10-10 | 2022-10-21 | 42 | 0d | Human Resources Working Group; Professional Association Working Group | 160h |
| 50 | 1.3.4.4 | Ensure appropriate positioning of professionalisation in line with other strategic interventions |  | 10d | 2022-10-24 | 2022-11-04 | 47, 48, 49 | 0d | Human Resources Working Group; Professional Association Working Group | 160h |
| 51 | 1.3.5 | Sign off for Organisation Capacity Development Plan | milestone | 1d | 2022-11-07 | 2022-11-07 | 50 | 0d |  |  |
| 52 | 1.4 | **S5: Implement and Monitor** |  | 271d | 2022-11-08 | 2023-11-21 |  | 0d |  | 10240h |
| 53 | 1.4.1 | **5.1 Rollout Approve Organisational Capacity Development Plan** |  | 270d | 2022-11-08 | 2023-11-20 |  | 0d |  | 8640h |
| 54 | 1.4.1.1 | Trigger planned interventions |  | 270d | 2022-11-08 | 2023-11-20 | 51 | 0d | Human Resources Working Group; Change Management Working Group | 4320h |
| 55 | 1.4.1.2 | Manage Planned interventions |  | 270d | 2022-11-08 | 2023-11-20 | 51 | 0d | Change Management Working Group; Human Resources Working Group | 4320h |

| ID | WBS | Task | Type | Duration | Start | Finish | Predecessors | Total slack | Resources | Work |
| --- | --- | --- | --- | --- | --- | --- | --- | --- | --- | --- |
| 56 | 1.4.2 | **5.2 Onboard for business as usual** |  | 20d | 2023-10-24 | 2023-11-20 |  | 0d |  | 1600h |
| 57 | 1.4.2.1 | Analyse total benefit |  | 20d | 2023-10-24 | 2023-11-20 | 53FS-20d | 0d | Change Management Working Group; Human Resources Working Group; Professional Association Working Group; Supply Chain Processes Working Group | 640h |
| 58 | 1.4.2.2 | Define ongoing structures |  | 20d | 2023-10-24 | 2023-11-20 | 53FS-20d | 0d | Human Resources Working Group; Professional Association Working Group | 320h |
| 59 | 1.4.2.3 | Begin process for review of Project Charter |  | 20d | 2023-10-24 | 2023-11-20 | 53FS-20d | 0d | Human Resources Working Group | 160h |
| 60 | 1.4.2.4 | Begin process for review Country Specific Job Descriptions |  | 20d | 2023-10-24 | 2023-11-20 | 53FS-20d | 0d | Human Resources Working Group | 160h |
| 61 | 1.4.2.5 | Begin process for review of Country Specific Designation Framework |  | 20d | 2023-10-24 | 2023-11-20 | 53FS-20d | 0d | Human Resources Working Group | 160h |
| 62 | 1.4.2.6 | Begin process for review Country Specific Education |  | 20d | 2023-10-24 | 2023-11-20 | 53FS-20d | 0d | Human Resources Working Group | 160h |
| 63 | 1.4.3 | Acquire sign off for Step 1 | milestone | 1d | 2023-11-21 | 2023-11-21 | 57, 58, 59, 60, 61, 62 | 0d |  |  |
